# 7.-CRONOGRAMA IE ANTONIO JOSE CAMACHO V3

Schedule from MS Project, 2020-12-14 to 2021-02-13.
UT-GMP

## Calendars

- proyecto camacho: Mon-Sat 07:00-12:00, 13:00-17:00; Sun off.

## Schedule

| ID | WBS | Task | Type | Duration | Start | Finish | Predecessors | Total slack | Free slack | Constraint |
| --- | --- | --- | --- | --- | --- | --- | --- | --- | --- | --- |
| 1 | 1 | **CRONOGRAMA IE ANTONIO JOSE CAMACHO** |  | 60d | 2020-12-14 | 2021-02-13 |  | 0d |  |  |
| 2 | 1.1 | INICIO | milestone | 0d | 2020-12-14 | 2020-12-14 |  | 60d |  |  |
| 3 | 1.2 | **PRELIMINARES** |  | 6.75d | 2020-12-14 | 2020-12-19 |  | 0d |  |  |
| 4 | 1.2.1 | IMPLEMENTACION PAPSO |  | 5d | 2020-12-14 | 2020-12-18 |  | 0d |  |  |
| 5 | 1.2.2 | **PRELIMINARES DE OBRA** |  | 1.75d | 2020-12-18 | 2020-12-19 | 4 | 0d |  |  |
| 6 | 1.2.2.1 | CAMPAMENTO Y ADECUACIONES |  | 1.75d | 2020-12-18 | 2020-12-19 |  | 0d |  |  |
| 7 | 1.2.2.2 | DEMOLICION CIMIENTOS (INC. RETIRO DE SOBR.) |  | 1d | 2020-12-18 | 2020-12-19 |  | 54d |  | finish no earlier than 2020-12-14 |
| 8 | 1.2.2.3 | DEMOLICIÓN DE PISOS EN BALDOSÍN (INC. RETIRO DE SOBR.) |  | 1d | 2020-12-18 | 2020-12-19 |  | 54d |  | finish no earlier than 2020-12-14 |
| 9 | 1.2.2.4 | DEMOLICION PLACA MACIZA H= 0.15 (INC. RETIRO DE SOBR.) |  | 1d | 2020-12-18 | 2020-12-19 |  | 5d | 0d | finish no earlier than 2020-12-14 |
| 10 | 1.3 | **CIMENTACION** |  | 33d | 2021-01-09 | 2021-02-13 |  | 0.25d |  |  |
| 11 | 1.3.1 | **EXCAVACIONES, RELLENOS Y REEMPLAZOS** |  | 33d | 2021-01-09 | 2021-02-13 |  | 0.25d |  |  |
| 12 | 1.3.1.1 | EXCAVACION MANUAL EN MATERIAL COMUN (incluye cargue y retiro) |  | 2d | 2021-01-09 | 2021-01-12 | 6FS+20d | 9.25d | 0d |  |
| 13 | 1.3.1.2 | CONCRETO PARA ZAPATAS 3000 PSI |  | 8d | 2021-01-09 | 2021-01-18 | 6FS+20d | 0.25d | 0d |  |
| 14 | 1.3.1.3 | RELLENO SUBBASE GRANULAR B-200 (Suministro, Extendido, Nivelación, Humedecimiento y Compactación). |  | 2d | 2021-01-22 | 2021-01-25 | 12FS+10d | 9.25d | 0d |  |
| 15 | 1.3.1.4 | ACERO DE REFUERZO 60000 PSI |  | 20d | 2021-01-23 | 2021-02-13 | 13FS+5d | 0.25d |  |  |
| 16 | 1.4 | **DESAGÜES E INSTALACIONES SUBTERRANEAS** |  | 5d | 2021-01-20 | 2021-01-26 |  | 18.25d |  |  |
| 17 | 1.4.1 | **CONSTRUCCIONES EN MAMPOSTERIA** |  | 5d | 2021-01-20 | 2021-01-26 |  | 18.25d |  |  |
| 18 | 1.4.1.1 | MARCOS CAJAS TAPAS DE INSPECCIÓN |  | 5d | 2021-01-20 | 2021-01-26 | 6FS+30d | 18.25d |  |  |
| 19 | 1.5 | **ESTRUCTURA** |  | 2d | 2021-01-25 | 2021-01-26 |  | 17.25d |  |  |
| 20 | 1.5.1 | CONCRETO PARA ESCALERAS 3000 PSI |  | 2d | 2021-01-25 | 2021-01-26 | 14 | 17.25d |  |  |
| 21 | 1.6 | **MAMPOSTERIA** |  | 14d | 2021-01-11 | 2021-01-26 |  | 18.25d |  |  |
| 22 | 1.6.1 | MURO EN DRY WALL DE 12 MM INCLUYE ESTRUCTURA METALICA , MASILLA , CINTA Y PRIMERA MANO DE PINTURA , VISTO DOS CARAS E=12 cms |  | 14d | 2021-01-11 | 2021-01-26 | 6FS+21d | 18.25d |  |  |
| 23 | 1.7 | **INSTALACIÓN HIDRAULICA SANITARIA Y DE GAS** |  | 16d | 2021-01-22 | 2021-02-08 |  | 5d |  |  |
| 24 | 1.7.1 | TUBERIA PVCP RDE 9 DE 1/2" |  | 14d | 2021-01-22 | 2021-02-06 | 9FS+33d | 7d |  |  |
| 25 | 1.7.2 | TUBERIA PVCP RDE 21 DE 3/4". |  | 12d | 2021-01-22 | 2021-02-04 | 9FS+33d | 9d |  |  |
| 26 | 1.7.3 | TUBERIA PVCP RDE 21 Ø 1" |  | 11d | 2021-01-22 | 2021-02-03 | 9FS+33d | 10d |  |  |
| 27 | 1.7.4 | TUBERIA PVCP RDE 21 Ø 1 1/2" |  | 16d | 2021-01-22 | 2021-02-08 | 9FS+33d | 5d |  |  |
| 28 | 1.7.5 | TUBERIA PVCP RDE 21 Ø 2" |  | 14d | 2021-01-22 | 2021-02-06 | 9FS+33d | 7d |  |  |
| 29 | 1.7.6 | TUBERIA PVC-P DE Ø 4" |  | 7d | 2021-01-22 | 2021-01-29 | 9FS+33d | 14d |  |  |

| ID | WBS | Task | Duration | Start | Finish | Predecessors | Total slack | Free slack |
| --- | --- | --- | --- | --- | --- | --- | --- | --- |
| 30 | 1.8 | **INSTALACIÓN ELECTRICA, TELEFÓNICA Y COMUNICACIONES** | 29d | 2020-12-30 | 2021-01-29 |  | 13d | 0d |
| 31 | 1.8.1 | **ACOMETIDAS Y CONDUCTORES** | 4d | 2021-01-15 | 2021-01-19 |  | 13d |  |
| 32 | 1.8.1.1 | TUBERIA EMT 3/4" - SUSPENDIDA INCLUYE ACCESORIOS Y FIJACIONES | 4d | 2021-01-15 | 2021-01-19 | 6FS+25d | 13d | 0d |
| 33 | 1.8.2 | **TABLEROS E INTERRUPTORES** | 7.5d | 2021-01-19 | 2021-01-27 |  | 13d |  |
| 34 | 1.8.2.1 | TABLERO DE AUTOMÁTICOS DE 18 CIRCUITOS TIPO PESADO CON PUERTA Y CERRADURA DE CIERRE, CERRADURA Y ESPACIO TOTALIZADOR INDUSTRIAL NTQ-412T Y BARRAJE DE TIERRA AISLADA. | 5d | 2021-01-19 | 2021-01-25 | 32 | 18d |  |
| 35 | 1.8.2.2 | TABLERO DE AUTOMÁTICOS DE 24 CIRCUITOS TIPO PESADO CON PUERTA Y CERRADURA DE CIERRE, CERRADURA Y ESPACIO TOTALIZADOR INDUSTRIAL NTQ-412T Y BARRAJE DE TIERRA AISLADA. | 2.5d | 2021-01-19 | 2021-01-21 | 32 | 13d | 0d |
| 36 | 1.8.2.3 | BREAKER RIEL MONOPOLAR 1 X 6/63 A | 7.5d | 2021-01-19 | 2021-01-27 | 32 | 15.5d |  |
| 37 | 1.8.2.4 | BREAKER RIEL BIPOLAR 2 X 20/50 A | 2.5d | 2021-01-19 | 2021-01-21 | 32 | 20.5d |  |
| 38 | 1.8.2.5 | BREAKER RIEL TRIPOLAR 1 X 40/63 A | 2.5d | 2021-01-22 | 2021-01-25 | 35 | 13d | 0d |
| 39 | 1.8.3 | **TELEVISION Y TELEFONOS** | 12.5d | 2020-12-30 | 2021-01-12 |  | 29.5d |  |
| 40 | 1.8.3.1 | CAJA DE PASO 10X10 | 12.5d | 2020-12-30 | 2021-01-12 | 6FS+10d | 29.5d |  |
| 41 | 1.8.4 | **CABLEADO ESTRUCTURADO, VOZ Y DATOS** | 10d | 2021-01-19 | 2021-01-29 |  | 13d |  |
| 42 | 1.8.4.1 | TOMACORRIENTE DOBLE POLO A TIERRA REGULADA COLOR NARANJA EN CANALETA | 10d | 2021-01-19 | 2021-01-29 | 32 | 13d |  |
| 43 | 1.8.4.2 | TOMACORRIENTE DOBLE POLO A TIERRA REGULADA | 10d | 2021-01-19 | 2021-01-29 | 32 | 13d |  |
| 44 | 1.8.5 | **APARATOS ELÉCTRICOS (INCLUYE SUM E INSTALACIÓN)** | 10d | 2021-01-19 | 2021-01-29 |  | 13d |  |
| 45 | 1.8.5.1 | INTERRUPTOR DOBLE ABITARE LUZ911 LP | 10d | 2021-01-19 | 2021-01-29 | 32 | 13d |  |
| 46 | 1.8.5.2 | INTERRUPTOR TRIPLE MARFIL LUZ913 LP | 10d | 2021-01-19 | 2021-01-29 | 32 | 13d |  |
| 47 | 1.9 | **PISOS** | 7d | 2021-01-20 | 2021-01-27 |  | 16.25d |  |
| 48 | 1.9.1 | BALDOSIN GRANITO L-1 DE 33x33 MORTERO 1:4 - (INCLUYE JUNTA DE DILATACION, DESTRONQUE, PULIDA Y BRILLADA) | 7d | 2021-01-20 | 2021-01-27 | 6FS+30d | 16.25d |  |
| 49 | 1.9.2 | PULIDA Y BRILLO GRANITO, INCLUYE TRATAMIENTO DE RESANES Y JUNTAS | 6d | 2021-01-20 | 2021-01-26 | 6FS+30d | 17.25d |  |
| 50 | 1.10 | **PAÑETES** | 3.75d | 2021-01-20 | 2021-01-23 |  | 8.25d | 0d |
| 51 | 1.10.1 | **PAÑETES SOBRE MUROS** | 3.75d | 2021-01-20 | 2021-01-23 |  | 8.25d |  |
| 52 | 1.10.1.1 | FILOS Y DILATACIONES | 3.75d | 2021-01-20 | 2021-01-23 | 6FS+30d | 18.25d |  |
| 53 | 1.10.1.2 | RESANES GENERALES | 3.75d | 2021-01-20 | 2021-01-23 | 6FS+30d | 8.25d | 0d |

| ID | WBS | Task | Duration | Start | Finish | Predecessors | Total slack | Free slack | Constraint |
| --- | --- | --- | --- | --- | --- | --- | --- | --- | --- |
| 54 | 1.11 | **CUBIERTAS E IMPERMEABILIZACIONES** | 25.75d | 2021-01-08 | 2021-02-03 |  | 0d |  |  |
| 55 | 1.11.1 | SUMINISTRO E INSTALACION DE CUBIERTA EN PANEL METALICO GALVANIZADO PREPINTADO CAL. 26 TIPO SANDWICH, INYECTADO EN LINEA CONTINUA CON POLIURETANO EXPANDIDO DE ALTA DENSIDAD 38 KG/M3 E=30 A 50 MM INCLUYE TAPAS DE BORDE DE CUBIERTA Y LOS ACCESORIOS NECESARIO | 7.5d | 2021-01-19 | 2021-01-27 | 56FS+6d | 15.5d |  |  |
| 56 | 1.11.2 | SUMINISTRO E INSTALACION DE ESTRUCTURA METALICA PARA CUBIERTAS. NORMA NSR10 TITULO F. PERFILERIA ASTM A572 GR50 Y ASTM A37. SOLDADURA E70XX. INC CERCHAS, CORREAS, TENSORES, ANCLAJES Y ACCESORIOS, LIMPIEZA SSPC-SP3, PINTURA ANTICORROSIVA 3 MILS Y ACABADO E | 5d | 2021-01-08 | 2021-01-13 | 6FS+18d | 0d |  |  |
| 57 | 1.11.3 | SUMINISTRO E INSTALACION DE CUBIERTA ALVEOLAR DE 8 MM TRANSPARENTE (INC. ESTRUCTURA METALICA DE CUBIERTA, PARALES, ELEMENTOS DE FIJACIÓN Y DEMÁS ACCESORIOS NECESARIOS PARA SU CORRECTO FUNCIONAMIENTO) | 10d | 2021-01-25 | 2021-02-03 | 53 | 8.25d |  |  |
| 58 | 1.11.4 | **ACCESORIOS Y OTROS** | 5d | 2021-01-11 | 2021-01-16 |  | 0d |  |  |
| 59 | 1.11.4.1 | SUMINISTRO E INSTALACION DE CANAL LAMINA GALVANIZADA Ds = 50 cm - CAL 20. INCLUYE SOPORTES, SOSCOS, REFUERZOS Y GARGOLAS DE REBOSE | 5d | 2021-01-11 | 2021-01-16 | 56FS-2d | 0d |  |  |
| 60 | 1.12 | **CARPINTERIA DE METÁLICA** | 30d | 2021-01-09 | 2021-02-10 |  | 3.25d |  |  |
| 61 | 1.12.1 | **CARPINTERIA EN LAMINA** | 30d | 2021-01-09 | 2021-02-10 |  | 3.25d |  |  |
| 62 | 1.12.1.1 | SUMINISTRO E INSTALACION DE PUERTA METALICA LAMINA C.R. C18 (ANTIC - ESMALTE) | 3d | 2021-01-16 | 2021-01-19 | 59 | 0d |  |  |
| 63 | 1.12.1.2 | REJA BANCARIA (ANTIC - ESMALTE) | 3d | 2021-01-09 | 2021-01-13 | 6FS+20d | 30.25d |  |  |
| 64 | 1.12.1.3 | BARANDA METALICA CORREDORES DE CIRCULACION, TUBO CIRCULAR EN ACERO GALVANIZADO DE 2" INCLINADO HACIA EL INTERIOR ANCLADA A BORDILLO DE CONCRETO CON PLATINAS DE 0,17 CM X 0,20 CM DE ACERO DE 1/4" Y CHAZO DE ANCLAJE DE 3/8" X 3" CON PLATINAS DE HIERRO LATER | 7d | 2021-02-03 | 2021-02-10 | 62FS+14d | 2.25d | 0d |  |
| 65 | 1.12.2 | **ENCHAPES** | 11d | 2021-01-20 | 2021-02-01 |  | 12.25d |  |  |
| 66 | 1.12.2.1 | **ENCHAPES SOBRE MUROS** | 11d | 2021-01-20 | 2021-02-01 |  | 12.25d |  |  |
| 67 | 1.12.2.1.1 | ENCHAPE PARED 25 x 35 - MACEDONIA CORONA Ó EQUIVALENTE | 11d | 2021-01-20 | 2021-02-01 | 6FS+30d | 12.25d |  |  |
| 68 | 1.13 | **APARATOS SANITARIOS Y ACCESORIOS** | 1.25d | 2021-01-19 | 2021-01-20 |  | 23d |  |  |
| 69 | 1.13.1 | **APARATOS SANITARIOS** | 1d | 2021-01-19 | 2021-01-20 |  | 23.25d |  |  |
| 70 | 1.13.1.1 | LAVAMANOS BLANCO ACUACER CON GRIFERIA (SUM E INSTALACION) | 1d | 2021-01-19 | 2021-01-20 | 32 | 23.25d |  |  |
| 71 | 1.13.2 | **ACCESORIOS** | 1.25d | 2021-01-19 | 2021-01-20 |  | 23d |  |  |
| 72 | 1.13.2.1 | BARRAS AYUDA MINUSVALIDOS (SUM E INSTALACION) | 1.25d | 2021-01-19 | 2021-01-20 | 32 | 23d |  |  |
| 73 | 1.14 | **PINTURA** | 22d | 2021-01-19 | 2021-02-11 |  | 0d |  |  |
| 74 | 1.14.1 | ANTICORROSIVO S/LÁMINA LINEAL | 1d | 2021-02-10 | 2021-02-11 | 64 | 2.25d |  | finish no earlier than 2020-12-14 |
| 75 | 1.14.2 | PINTURA ESMALTE S/LÁMINA LINEAL | 1d | 2021-02-10 | 2021-02-11 | 64 | 2.25d |  | finish no earlier than 2020-12-14 |
| 76 | 1.14.3 | HIDROFUGO FACHADAS | 10d | 2021-01-19 | 2021-01-29 | 62 | 14.25d |  |  |
| 77 | 1.14.4 | SUMINISTRO E INSTALACION DE PINTURA EPOXICA PARA PISOS, MUROS Y TECHOS INCLUYE PREPARACION DE SUPERFICIE Y PRIMER DE ADHERENCIA | 3.75d | 2021-01-19 | 2021-01-23 | 62 | 0d |  |  |

| ID | WBS | Task | Duration | Start | Finish | Predecessors | Total slack | Free slack | Constraint |
| --- | --- | --- | --- | --- | --- | --- | --- | --- | --- |
| 78 | 1.15 | **CERRADURAS Y VIDRIOS** | 4.25d | 2021-01-23 | 2021-01-27 |  | 0d |  |  |
| 79 | 1.15.1 | **CERRADURAS** | 3d | 2021-01-23 | 2021-01-26 |  | 0d |  |  |
| 80 | 1.15.1.1 | CERRADURA SCHLAGE ENTRADA A-80 PD | 3d | 2021-01-23 | 2021-01-26 | 77 | 0d |  |  |
| 81 | 1.15.2 | **VIDRIOS Y ESPEJOS** | 1.25d | 2021-01-26 | 2021-01-27 |  | 16.25d |  |  |
| 82 | 1.15.2.1 | SUMINISTRO E INSTALACION DE VIDRIO DE SEGURIDAD LAMINADO 3+3 | 1.25d | 2021-01-26 | 2021-01-27 | 80 | 16.25d |  |  |
| 83 | 1.16 | **OBRAS EXTERIORES** | 10d | 2021-01-25 | 2021-02-04 |  | 9.25d |  |  |
| 84 | 1.16.1 | **ZONAS DURAS Y PLAZOLETAS** | 10d | 2021-01-25 | 2021-02-04 |  | 9.25d |  |  |
| 85 | 1.16.1.1 | CONCRETO ESCOBEADO PARA ANDENES O RAMPAS H = 10 cm - 3000 PSI CERTIFICADO | 10d | 2021-01-25 | 2021-02-04 | 14 | 9.25d |  |  |
| 86 | 1.17 | **OBRAS NO PREVISTAS** | 31.25d | 2021-01-12 | 2021-02-13 |  | 0d |  |  |
| 87 | 1.17.1 | SELLO DE JUNTAS PARA DILATACIÓN MUROS | 1d | 2021-01-12 | 2021-01-13 | 12 | 30.25d |  | finish no earlier than 2020-10-27 |
| 88 | 1.17.2 | SUMINISTRO E INSTALACION CABLE LIBRE DE HALOGENOS 3X12 | 1d | 2021-01-12 | 2021-01-13 | 12 | 30.25d |  | finish no earlier than 2020-10-27 |
| 89 | 1.17.3 | PRUEBAS HIDROSANITARIAS Y ELECTRICAS PARA VERIFICAR EL ESTADO ACTUAL DE LAS REDES EXISTENTES. | 1d | 2021-01-12 | 2021-01-13 | 12 | 30.25d |  | finish no earlier than 2020-10-27 |
| 90 | 1.17.4 | DILATACIONES VERTICALES ZONA COMEDOR | 1.25d | 2021-01-25 | 2021-01-26 | 50 | 18.25d |  |  |
| 91 | 1.17.5 | DILATACIONES HORIZONTALES ZONA COMEDOR | 1.25d | 2021-01-25 | 2021-01-26 | 50 | 18.25d |  |  |
| 92 | 1.17.6 | SUMINISTRO E INSTALACIÓN DE SOLAPA PARA TEJAS | 1.25d | 2021-02-03 | 2021-02-04 | 54 | 8.25d |  |  |
| 93 | 1.17.7 | IMPERMEABILIZACIÓN DE UNIÓN EN CANAL | 1.25d | 2021-02-03 | 2021-02-04 | 54 | 8.25d |  |  |
| 94 | 1.17.8 | IMPERMEABILIZACIÓN DE BAJANTES | 1.25d | 2021-02-03 | 2021-02-04 | 54 | 8.25d |  |  |
| 95 | 1.17.9 | LAVADO DE FACHADAS | 1.25d | 2021-01-13 | 2021-01-14 | 108 | 29d |  |  |
| 96 | 1.17.10 | SERVICIO INSPECCION DE RETIE,TABLERO GENERAL DE BAJA TENSON,ALIMANTADORES A TABLEROS DE | 1.25d | 2021-01-29 | 2021-01-30 | 30 | 13d |  |  |
| 97 | 1.17.11 | MURO CALADO CEMENTO | 1d | 2021-01-12 | 2021-01-13 | 12 | 30.25d |  | finish no earlier than 2020-10-27 |
| 98 | 1.17.12 | SERVICIO INSPECCION DE RETIE,TABLERO GENERAL DE BAJA TENSON,ALIMANTADORES A TABLEROS DE DISTRIBUCION,CIRCUITOS DE SALIDAS,TOMAS ,ILUMINACION Y PUESTA A TIERRA | 1d | 2021-01-12 | 2021-01-13 | 12 | 30.25d |  | finish no earlier than 2020-10-27 |
| 99 | 1.17.13 | LIJADO PARA BARANDA EXISTENTE | 5d | 2021-01-26 | 2021-02-01 | 80 | 3.25d | 0d |  |
| 100 | 1.17.14 | AJUSTE Y SOLDADURA DE PUERTA DE ACCESO (INCLUYE PINTURA) | 5.5d | 2021-02-01 | 2021-02-06 | 99 | 3.25d | 0d |  |
| 101 | 1.17.15 | LIMPIEZA Y PULIDAD DE GUARDAESCOBAS | 12.5d | 2021-01-26 | 2021-02-08 | 80 | 0d |  |  |
| 102 | 1.17.16 | PINTURA DE CARCAMOS METALICOS | 3.75d | 2021-02-06 | 2021-02-10 | 100 | 3.25d |  |  |
| 103 | 1.17.17 | SUMINISTRO E INSTALACIÓN DE MEDIA CAÑA PVC | 2.5d | 2021-02-06 | 2021-02-09 | 100 | 4.5d |  |  |
| 104 | 1.17.18 | SUMINISTRO, INSTALACIÓN Y CONEXIÓN LÁMPARA SOBREPONER LED 2X18W | 5d | 2021-02-08 | 2021-02-13 | 101 | 0d |  |  |
| 105 | 1.17.19 | SUMINISTRO, INSTALACIÓN Y CONEXIÓN SENSOR DE MOVIMIENTO PARA TECHO | 2d | 2021-01-25 | 2021-01-26 | 38 | 14.75d | 0d |  |
| 106 | 1.17.20 | SUMINISTRO E INSTALACIÓN DE CABLE ENCAUCHETADO 3X14 ALIMENTACIÓN LÁMPARAS, INCLUYE CLAVIJA | 6.25d | 2021-01-25 | 2021-01-30 | 38 | 13d |  |  |
| 107 | 1.17.21 | DISPOSITIVO DE PROTECCIÓN CONTRA SOBRETENSIONES TIPO II CLASE C | 2.5d | 2021-01-27 | 2021-01-29 | 105 | 14.75d |  |  |
| 108 | 1.17.22 | SUMINISTRO E INSTALACIÓN DE ANCLAJE FALTANTES DE TUBERIAS Y BANDEJAS PORTACABLES EXISTENTES | 1d | 2021-01-12 | 2021-01-13 | 12 | 28.25d | 0d | start no earlier than 2020-10-27 |
| 109 | 1.17.23 | SUMINISTRO E INSTALACIÓN DE LAVAPLATOS EN ACERO INOXIDABLE | 2d | 2021-01-13 | 2021-01-15 | 108 | 28.25d |  |  |
| 110 | 1.17.24 | CORTE Y RESANE DE REGATAS SOBRE MUROES EN BLOQUE CEMENTO | 8d | 2021-01-15 | 2021-01-23 | 6FS+25d | 20.25d |  |  |
| 111 | 1.17.25 | PINTURA DE ESTRUCTURA METÁLICA EN PASILLO | 15d | 2021-01-15 | 2021-01-30 | 6FS+25d | 13.25d |  |  |

| ID | WBS | Task | Type | Duration | Start | Finish | Predecessors | Total slack | Free slack | Constraint |
| --- | --- | --- | --- | --- | --- | --- | --- | --- | --- | --- |
| 112 | 1.18 | **ASEO Y VARIOS** |  | 1.25d | 2021-01-13 | 2021-01-14 |  | 29d |  |  |
| 113 | 1.18.1 | **ASEO Y LIMPIEZA** |  | 1.25d | 2021-01-13 | 2021-01-14 |  | 29d |  |  |
| 114 | 1.18.1.1 | ASEO GENERAL |  | 1.25d | 2021-01-13 | 2021-01-14 | 108 | 29d |  |  |
| 115 | 1.19 | **CRONOGRAMA ASCENSOR IE ANTONIO JOSE CAMACHO** |  | 46d | 2020-12-18 | 2021-02-04 |  | 9d |  |  |
| 116 | 1.19.1 | INICIO | milestone | 0d | 2021-01-05 | 2021-01-05 | 6FS+15d | 38.25d |  | finish no earlier than 2020-10-13 |
| 117 | 1.19.2 | ADECUACIONES CIVILES DE FOSO E INSTALACION DE ESTRUCTURA METALICA SOPORTE ELEVAPERSONAS |  | 28d | 2020-12-18 | 2021-01-16 | 6SS | 9d | 0d | finish no earlier than 2020-10-13 |
| 118 | 1.19.3 | FIN ADECUACIONES CIVILES Y ESTRUCTURA METALICA | milestone | 0d | 2021-01-16 | 2021-01-16 | 117 | 27d |  | finish no earlier than 2020-10-14 |
| 119 | 1.19.4 | INSTALACIÓN ELECTRICA, Y CONEXIONES DE EQUIPO Y PUESTA EN MARCHA DE ELEVAPERSONAS |  | 18d | 2021-01-16 | 2021-02-04 | 117 | 9d | 0d | finish no earlier than 2020-10-13 |
| 120 | 1.19.5 | FIN | milestone | 0d | 2021-02-04 | 2021-02-04 | 119 | 9d |  | finish no earlier than 2020-10-13 |
